# LICEO COPEYITO

Schedule from MS Project, 2021-04-06 to 2021-06-05.

## Calendars

- Copia de Estándar: Mon-Sat 07:30-12:00, 13:30-17:00; Sun off.

## Schedule

| ID | WBS | Task | Type | Duration | Start | Finish | Predecessors | Total slack |
| --- | --- | --- | --- | --- | --- | --- | --- | --- |
| 1 | 1 | LIMPIEZA GENERAL DE EXTERIOR PRODUCTO DEL TIEMPO DETENIDO | manual | 5d | 2021-04-06 | 2021-04-10 |  |  |
| 2 | 2 | **MODULO B-1** |  | 52.19d | 2021-04-06 | 2021-06-05 | 1 | 0d |
| 3 | 2.1 | PINTURA GENERAL | manual | 12d | 2021-04-12 | 2021-04-26 | 1 |  |
| 4 | 2.2 | PULIDO Y BRILLADO DE PISOS | manual | 18d | 2021-04-28 | 2021-05-19 | 3 |  |
| 5 | 2.3 | INSTALACIONES SANITARIAS EN GENERAL | manual | 20d | 2021-05-13 | 2021-06-05 | 4FS-7d |  |
| 6 | 2.4 | IMPERMEABILIZANTE DE TECHO | manual | 5d | 2021-04-06 | 2021-04-10 |  |  |
| 7 | 2.5 | INSTALACIONES ELECTRICAS EN GENERAL | manual | 15d | 2021-04-28 | 2021-05-15 | 3 |  |
| 8 | 3 | **MODULO B-2** |  | 51.19d | 2021-04-06 | 2021-06-04 | 1 | 0d |
| 9 | 3.1 | PINTURA GENERAL | manual | 12d | 2021-04-12 | 2021-04-26 | 1 |  |
| 10 | 3.2 | PULIDO Y BRILLADO DE PISOS | manual | 18d | 2021-04-28 | 2021-05-19 | 9 |  |
| 11 | 3.3 | INSTALACIONES SANITARIAS EN GENERAL | manual | 15d | 2021-05-18 | 2021-06-04 | 10FS-4d |  |
| 12 | 3.4 | IMPERMEABILIZANTE DE TECHO | manual | 5d | 2021-04-06 | 2021-04-10 |  |  |
| 13 | 3.5 | INSTALACIONES ELECTRICAS EN GENERAL | manual | 15d | 2021-04-28 | 2021-05-15 | 9 |  |
| 14 | 4 | **CANCHA** |  | 10.19d | 2021-04-12 | 2021-04-24 | 1 | 0d |
| 15 | 4.1 | PINTURA EN CANCHA | manual | 4d | 2021-04-12 | 2021-04-16 | 1 |  |
| 16 | 4.2 | PINTURA EN BRAZOS DE CANCHA | manual | 2d | 2021-04-16 | 2021-04-19 | 15 |  |
| 17 | 4.3 | COLOCACION TABLEROS DE CANCHA | manual | 1d | 2021-04-20 | 2021-04-21 | 16 |  |
| 18 | 4.4 | INSTALACION POSTES DE VOLLEYBALL | manual | 2d | 2021-04-22 | 2021-04-24 | 15FS+4d |  |
| 19 | 5 | **COMEDOR TIPO A-220** |  | 21.19d | 2021-04-12 | 2021-05-07 | 1 | 0d |
| 20 | 5.1 | PINTURA EN GENERAL | manual | 5d | 2021-04-12 | 2021-04-17 | 1 |  |
| 21 | 5.2 | INSTALACION ELECTRICA | manual | 10d | 2021-04-26 | 2021-05-07 | 20 |  |
| 22 | 5.3 | IMPERMEABILIZANTE EN GENERAL | manual | 4d | 2021-04-12 | 2021-04-16 | 20SS |  |
| 23 | 6 | **AREA EXTERIOR** |  | 37.19d | 2021-04-12 | 2021-05-26 | 1 | 0d |
| 24 | 6.1 | ENTRADA PRINCIPAL PORTON | manual | 20d | 2021-04-12 | 2021-05-05 | 1 |  |
| 25 | 6.2 | AREA CIVICA, TARJA Y ASTA DE BANDERA | manual | 25d | 2021-04-12 | 2021-05-11 | 1 |  |
| 26 | 6.3 | PARQUEOS | manual | 15d | 2021-05-03 | 2021-05-20 | 25 |  |
| 27 | 6.4 | JARDINERIA EN GENERAL | manual | 20d | 2021-05-03 | 2021-05-26 | 25 |  |
| 28 | 6.5 | INSTALACION ELECTRICA | manual | 7d | 2021-05-03 | 2021-05-11 | 25 |  |
