# PEDRO MARIA BURGOS

Schedule from MS Project, 2021-04-06 to 2021-07-26.

## Calendars

- Estándar: Mon-Fri 09:00-13:00, 15:00-19:00; Sat-Sun off.

## Schedule

| ID | WBS | Task | Type | Duration | Start | Finish | Predecessors | Total slack |
| --- | --- | --- | --- | --- | --- | --- | --- | --- |
| 1 | 1 | **MODULO B-1** |  | 45d | 2021-04-06 | 2021-06-07 |  | 0d |
| 2 | 1.1 | PINTURA GENERAL | manual | 12d | 2021-04-06 | 2021-04-21 |  |  |
| 3 | 1.2 | PULIDO Y BRILLADO DE PISOS | manual | 18d | 2021-04-22 | 2021-05-17 | 2 |  |
| 4 | 1.3 | IMPERMEABILIZANTE DE TECHO | manual | 6d | 2021-04-06 | 2021-04-13 | 2SS |  |
| 5 | 1.4 | INSTALACION SANITARIA | manual | 15d | 2021-05-18 | 2021-06-07 | 3 |  |
| 6 | 1.5 | INSTALACIONES ELECTRICAS | manual | 15d | 2021-04-22 | 2021-05-12 | 2 |  |
| 8 | 2 | **MODULO AULA INICIAL** |  | 45d | 2021-04-06 | 2021-06-07 |  | 0d |
| 9 | 2.1 | PINTURA GENERAL | manual | 12d | 2021-04-06 | 2021-04-21 |  |  |
| 10 | 2.2 | PULIDO Y BRILLADO DE PISOS | manual | 18d | 2021-04-22 | 2021-05-17 | 9 |  |
| 11 | 2.3 | IMPERMEABILIZANTE DE TECHO | manual | 6d | 2021-04-06 | 2021-04-13 | 9SS |  |
| 12 | 2.4 | INSTALACION SANITARIA | manual | 15d | 2021-05-18 | 2021-06-07 | 10 |  |
| 13 | 2.5 | INSTALACIONES ELECTRICAS | manual | 15d | 2021-04-22 | 2021-05-12 | 9 |  |
| 15 | 3 | **COMEDOR TIPO II** |  | 35d | 2021-04-06 | 2021-05-24 |  | 0d |
| 16 | 3.1 | TECHO EN ALUZIN | manual | 20d | 2021-04-06 | 2021-05-03 |  |  |
| 17 | 3.2 | REVESTIMIENTO LADRILLOS | manual | 7d | 2021-04-06 | 2021-04-14 | 16SS |  |
| 18 | 3.3 | PUERTAS EN GENERAL | manual | 10d | 2021-04-06 | 2021-04-19 | 16SS |  |
| 19 | 3.4 | PINTURA EN GENERAL | manual | 15d | 2021-04-22 | 2021-05-12 | 17 |  |
| 20 | 3.5 | INSTALACION ELECTRICA | manual | 15d | 2021-05-04 | 2021-05-24 | 16 |  |
| 21 | 3.6 | INSTALACION SANITARIA | manual | 15d | 2021-05-04 | 2021-05-24 | 20SS |  |
| 23 | 4 | **CANCHA** |  | 25d | 2021-04-06 | 2021-05-10 |  | 0d |
| 24 | 4.1 | GRADA EN CANCHA | manual | 25d | 2021-04-06 | 2021-05-10 |  |  |
| 25 | 4.2 | RESANE DE TORTA DE CANCHA | manual | 15d | 2021-04-06 | 2021-04-26 | 24SS |  |
| 26 | 4.3 | PINTURA EN BRAZOS DE CANCHA | manual | 2d | 2021-04-27 | 2021-04-28 | 25 |  |
| 27 | 4.4 | PINTURA CANCHA | manual | 4d | 2021-04-29 | 2021-05-04 | 25FS+2d |  |
| 28 | 4.5 | TABLEROS DE CANCHA | manual | 1d | 2021-04-29 | 2021-04-29 | 26 |  |
| 29 | 4.6 | POSTES DE VOLLEYBALL | manual | 3d | 2021-05-05 | 2021-05-07 | 27 |  |

| ID | WBS | Task | Type | Duration | Start | Finish | Predecessors | Total slack |
| --- | --- | --- | --- | --- | --- | --- | --- | --- |
| 31 | 5 | **MODULOS EXISTENTES** |  | 80d | 2021-04-06 | 2021-07-26 |  | 0d |
| 32 | 5.1 | TERMINACION DE SUPERFICIES | manual | 20d | 2021-04-06 | 2021-05-03 |  |  |
| 33 | 5.2 | PINTURA EN GENERAL | manual | 20d | 2021-05-18 | 2021-06-14 | 32 |  |
| 34 | 5.3 | REPARACION DE PUERTAS Y VENTANAS | manual | 15d | 2021-06-22 | 2021-07-12 | 33 |  |
| 35 | 5.4 | RESANES EN ACERAS | manual | 18d | 2021-05-18 | 2021-06-10 | 32 |  |
| 36 | 5.5 | IMPERMEABILIZANTE EN GENERAL | manual | 25d | 2021-06-22 | 2021-07-26 | 32 |  |
| 37 | 5.6 | REPARACION SANITARIA | manual | 18d | 2021-04-06 | 2021-04-29 | 32SS |  |
| 38 | 5.7 | REPARACION ELECTRICA | manual | 18d | 2021-04-06 | 2021-04-29 | 32SS |  |
| 40 | 6 | **AREA EXTERIOR** |  | 30d | 2021-04-06 | 2021-05-17 |  | 0d |
| 41 | 6.1 | ENTRADA PRINCIPAL | manual | 30d | 2021-04-06 | 2021-05-17 |  |  |
| 42 | 6.2 | SOLUCION PLUVIAL | manual | 25d | 2021-04-06 | 2021-05-10 | 41SS |  |
| 43 | 6.3 | SOLUCION SANITARIA | manual | 25d | 2021-04-06 | 2021-05-10 | 42SS |  |
| 44 | 6.4 | JARDINERIA EN GENERAL | manual | 25d | 2021-04-06 | 2021-05-10 | 41SS |  |
| 45 | 6.5 | INSTALACION ELECTRICA | manual | 20d | 2021-04-06 | 2021-05-03 |  |  |
