# RIO SAN JUAN 1

Schedule from MS Project, 2021-04-06 to 2021-07-12.

## Calendars

- Estándar: Mon-Fri 09:00-13:00, 15:00-19:00; Sat-Sun off.

## Schedule

| ID | WBS | Task | Type | Duration | Start | Finish | Predecessors | Total slack |
| --- | --- | --- | --- | --- | --- | --- | --- | --- |
| 1 | 1 | **MODULO B-1** |  | 55d | 2021-04-06 | 2021-06-21 |  | 0d |
| 2 | 1.1 | PINTURA GENERAL | manual | 12d | 2021-04-06 | 2021-04-21 |  |  |
| 3 | 1.2 | PULIDO Y BRILLADO DE PISOS | manual | 18d | 2021-04-22 | 2021-05-17 | 2 |  |
| 4 | 1.3 | IMPERMEABILIZANTE DE TECHO | manual | 5d | 2021-04-06 | 2021-04-12 | 2SS |  |
| 5 | 1.4 | INSTALACION SANITARIA | manual | 25d | 2021-05-18 | 2021-06-21 | 3 |  |
| 6 | 1.5 | INSTALACIONES ELECTRICAS | manual | 15d | 2021-04-22 | 2021-05-12 | 2 |  |
| 8 | 2 | **MODULO B-2** |  | 45d | 2021-04-06 | 2021-06-07 |  | 0d |
| 9 | 2.1 | PINTURA GENERAL | manual | 12d | 2021-04-06 | 2021-04-21 |  |  |
| 10 | 2.2 | PULIDO Y BRILLADO DE PISOS | manual | 18d | 2021-04-22 | 2021-05-17 | 9 |  |
| 11 | 2.3 | IMPERMEABILIZANTE DE TECHO | manual | 6d | 2021-04-06 | 2021-04-13 | 9SS |  |
| 12 | 2.4 | INSTALACION SANITARIA | manual | 15d | 2021-05-18 | 2021-06-07 | 10 |  |
| 13 | 2.5 | INSTALACIONES ELECTRICAS | manual | 15d | 2021-04-22 | 2021-05-12 | 9 |  |
| 15 | 3 | **COMEDOR TIPO I** |  | 31d | 2021-04-06 | 2021-05-18 |  | 0d |
| 16 | 3.1 | TECHO EN ALUZIN | manual | 16d | 2021-04-06 | 2021-04-27 |  |  |
| 17 | 3.2 | REVESTIMIENTO LADRILLOS | manual | 7d | 2021-04-06 | 2021-04-14 |  |  |
| 18 | 3.3 | PUERTAS EN GENERAL | manual | 7d | 2021-04-06 | 2021-04-14 |  |  |
| 19 | 3.4 | INSTALACION ELECTRICA | manual | 15d | 2021-04-28 | 2021-05-18 | 16 |  |
| 20 | 3.5 | INSTALACION SANITARIA | manual | 15d | 2021-04-06 | 2021-04-26 |  |  |
| 21 | 3.6 | PINTURA (Tropical) | manual | 6d | 2021-04-15 | 2021-04-22 | 17 |  |
| 23 | 4 | **CANCHA Y GRADAS** |  | 13d | 2021-04-06 | 2021-04-22 |  | 0d |
| 24 | 4.1 | PINTURA EN BRAZOS DE CANCHA | manual | 2d | 2021-04-06 | 2021-04-07 |  |  |
| 25 | 4.2 | PINTURA CANCHAS | manual | 4d | 2021-04-06 | 2021-04-09 | 24SS |  |
| 26 | 4.3 | PINTURA EN GRADAS | manual | 3d | 2021-04-06 | 2021-04-08 | 24SS |  |
| 27 | 4.4 | COLOCACION TABLEROS EN CANCHA | manual | 2d | 2021-04-12 | 2021-04-13 | 24FS+2d |  |
| 28 | 4.5 | BARANDAS EN CANCHAS | manual | 7d | 2021-04-14 | 2021-04-22 | 25FS+2d |  |

| ID | WBS | Task | Type | Duration | Start | Finish | Predecessors | Total slack |
| --- | --- | --- | --- | --- | --- | --- | --- | --- |
| 30 | 5 | **AREA EXTERIOR** |  | 70d | 2021-04-06 | 2021-07-12 |  | 0d |
| 31 | 5.1 | SOLUCION PLUVIAL | manual | 45d | 2021-04-06 | 2021-06-07 |  |  |
| 32 | 5.2 | SOLUCION SANITARIA | manual | 25d | 2021-04-06 | 2021-05-10 | 31SS |  |
| 33 | 5.3 | JARDINERIA EN GENERAL | manual | 25d | 2021-04-06 | 2021-05-10 | 31SS |  |
| 34 | 5.4 | INSTALACION ELECTRICA | manual | 25d | 2021-04-06 | 2021-05-10 |  |  |
| 35 | 5.5 | REFORZAMIENTO EN VERJA TRASERA | manual | 45d | 2021-04-06 | 2021-06-07 |  |  |
| 36 | 5.6 | TERMINACION VERJA PERIMETRAL Y ENTRADA PRINCIPAL | manual | 25d | 2021-06-08 | 2021-07-12 | 35 |  |
| 37 | 5.7 | PLAZA CIVICA Y ACERAS DE INTERCONEXION | manual | 25d | 2021-04-06 | 2021-05-10 |  |  |
| 38 | 5.8 | TARJA Y ASTA DE BANDERA | manual | 10d | 2021-05-11 | 2021-05-24 | 37 |  |
