# ESCUELA BASICA CAMBITA 23-11-2017

Schedule from MS Project, 2021-04-01 to 2021-11-20, costs in $ RD.
Windows uE

## Calendars

- Estándar: Mon-Fri 08:00-12:00, 13:00-17:00; Sat 08:00-12:00; Sun off.

## Schedule

| ID | WBS | Task | Type | Duration | Start | Finish | Predecessors | Total slack | Free slack | Cost |
| --- | --- | --- | --- | --- | --- | --- | --- | --- | --- | --- |
| 1 | 1 | **PROYECTO: CONSTRUCCION DE LA ESCUELA BASICA CAMBITA GARABITOS** |  | 142.62d | 2021-04-01 | 2021-09-29 |  |  |  | 67,850,315.92 |
| 2 | 1.2 | **II. BLOQUE B1** |  | 122.5d | 2021-04-01 | 2021-09-03 |  | -41.38d | 0d | 21,343,837.15 |
| 3 | 1.2.1 | **>>PRIMER NIVEL.<<** |  | 80d | 2021-04-01 | 2021-07-12 |  | -41.38d | 0d | 5,074,627.51 |
| 4 | 1.2.1.1 | A. LIMPIEZA Y REPLANTEO | milestone | 0d | 2021-04-01 | 2021-04-01 |  | -41.38d | 0d | 10,000 |
| 5 | 1.2.1.2 | B. BAJO NIVEL DE PISO | milestone | 0d | 2021-04-01 | 2021-04-01 | 4 | -41.38d | 0d | 832,000 |
| 6 | 1.2.1.3 | **C. SOBRE NIVEL DE PISO** |  | 80d | 2021-04-01 | 2021-07-12 | 5 | -41.38d | 0d | 4,232,627.51 |
| 7 | 1.2.1.3.1 | 1. HORMIGON ARMADO |  | 25d | 2021-04-01 | 2021-05-03 |  | -41.38d | 0d | 1,729,715.77 |
| 8 | 1.2.1.3.2 | 2. MUROS DE BLOQUES |  | 11d | 2021-04-20 | 2021-05-04 | 7FS-10d | -41.38d | 0d | 286,499.31 |
| 9 | 1.2.1.3.3 | 3. TERMINACION DE SUPERFICIES |  | 14d | 2021-05-04 | 2021-05-21 | 8 | -41.38d | 0d | 335,008.92 |
| 10 | 1.2.1.3.4 | 4. TERMINACION DE PISOS |  | 9d | 2021-05-10 | 2021-05-20 | 9FS-10d | -10.38d | 0d | 492,691.88 |
| 11 | 1.2.1.3.5 | 5. TERMINACION DE ESCALERA |  | 5d | 2021-05-21 | 2021-05-27 | 9 | -6.38d | 0d | 90,152.01 |
| 12 | 1.2.1.3.6 | 7. PUERTAS |  | 9d | 2021-05-21 | 2021-06-02 | 9 | -18.38d | 0d | 338,041 |
| 13 | 1.2.1.3.7 | 8. PROTECTORES METALICOS |  | 8d | 2021-06-02 | 2021-06-11 | 12 | -18.38d | 0d | 190,625.7 |
| 14 | 1.2.1.3.8 | 9. REVESTIMIENTO EN BANOS |  | 5d | 2021-05-27 | 2021-06-02 | 10FS+5d | -10.38d | 0d | 74,132.37 |
| 15 | 1.2.1.3.9 | 10. INSTALACION SANITARIA |  | 8d | 2021-05-11 | 2021-06-10 | 8FS+5d | -16.88d | 0d | 139,120.19 |
| 16 | 1.2.1.3.10 | 11. PLAFOND |  | 9d | 2021-05-21 | 2021-06-02 | 9 | -10.38d | 0d | 24,180 |
| 17 | 1.2.1.3.11 | 12. ACERA PERIMETRAL |  | 5d | 2021-05-21 | 2021-05-27 | 9 | -13.38d | 0d | 78,604.43 |
| 18 | 1.2.1.3.12 | 13. PINTURA |  | 11d | 2021-06-01 | 2021-07-12 | 9FS+8d | -41.38d | 0d | 228,619.63 |
| 19 | 1.2.1.3.13 | 14. VARIOS |  | 7d | 2021-05-28 | 2021-06-05 | 17 | -13.38d | 0d | 225,236.3 |
| 20 | 1.2.2 | **>> SEGUNDO NIVEL <<** |  | 87d | 2021-05-03 | 2021-08-20 |  | 20.12d |  | 5,962,343.28 |
| 21 | 1.2.2.1 | 1. REPLANTEO |  | 3d | 2021-05-03 | 2021-05-06 | 7 | 20.12d | 0d | 1,729,715.77 |
| 22 | 1.2.2.2 | 2. HORMIGON ARMADO |  | 25d | 2021-05-06 | 2021-06-07 | 21 | 20.12d | 0d | 1,729,715.77 |
| 23 | 1.2.2.3 | 3. MUROS DE BLOQUES |  | 11d | 2021-06-01 | 2021-06-15 | 22FS-5d | 30.62d | 0d | 286,499.31 |
| 24 | 1.2.2.4 | 4. TERMINACION DE SUPERFICIES |  | 9d | 2021-06-15 | 2021-06-25 | 23 | 30.62d | 0d | 335,008.92 |
| 25 | 1.2.2.5 | 5. TERMINACION DE PISOS |  | 9d | 2021-06-26 | 2021-07-07 | 24 | 65.62d |  | 492,691.88 |
| 26 | 1.2.2.6 | 6. TERMINACION DE ESCALERA |  | 8d | 2021-06-15 | 2021-06-24 | 23 | 70.62d | 0d | 90,152.01 |
| 27 | 1.2.2.7 | 7. VENTANAS |  | 7d | 2021-06-26 | 2021-07-05 | 24 | 67.62d |  | 338,041 |
| 28 | 1.2.2.8 | 8. PUERTAS |  | 9d | 2021-06-26 | 2021-07-07 | 24 | 65.62d |  | 190,625.7 |
| 29 | 1.2.2.9 | 9. BARANDA |  | 5d | 2021-06-25 | 2021-07-01 | 26 | 70.62d |  | 74,132.37 |
| 30 | 1.2.2.10 | 10. REVESTIMIENTO EN BANO |  | 9d | 2021-06-26 | 2021-07-07 | 24 | 65.62d |  | 139,120.19 |
| 31 | 1.2.2.11 | 11. INSTALACION SANITARIA |  | 9d | 2021-06-26 | 2021-07-07 | 24 | 54.62d | 0d | 24,180 |
| 32 | 1.2.2.12 | 12. PLAFOND |  | 9d | 2021-06-26 | 2021-07-07 | 24 | 65.62d |  | 78,604.43 |
| 33 | 1.2.2.13 | 13. PINTURA |  | 11d | 2021-06-26 | 2021-08-20 | 24 | 30.62d | 0d | 228,619.63 |
| 34 | 1.2.2.14 | 14. VARIOS |  | 9d | 2021-06-26 | 2021-07-07 | 33SS | 65.62d |  | 225,236.3 |

| ID | WBS | Task | Duration | Start | Finish | Predecessors | Total slack | Free slack | Cost |
| --- | --- | --- | --- | --- | --- | --- | --- | --- | --- |
| 35 | 1.2.3 | **>> TERCER NIVEL <<** | 69.5d | 2021-06-08 | 2021-09-03 |  | 20.12d |  | 6,630,879.21 |
| 36 | 1.2.3.1 | 1. REPLANTEO | 3d | 2021-06-08 | 2021-06-10 | 22 | 20.12d | 0d | 668,535.93 |
| 37 | 1.2.3.2 | 2. HORMIGON ARMADO | 25d | 2021-06-11 | 2021-07-13 | 36 | 20.12d | 0d | 1,729,715.77 |
| 38 | 1.2.3.3 | 3. MUROS DE BLOQUES | 11d | 2021-07-07 | 2021-07-20 | 37FS-5d | 20.12d | 0d | 286,499.31 |
| 39 | 1.2.3.4 | 4. TERMINACION DE SUPERFICIES | 9d | 2021-07-21 | 2021-07-31 | 38 | 20.12d | 0d | 335,008.92 |
| 40 | 1.2.3.5 | 5. TERMINACION DE PISOS | 9d | 2021-08-02 | 2021-08-12 | 39 | 37.62d |  | 492,691.88 |
| 41 | 1.2.3.6 | 6. TERMINACION DE TECHO | 5d | 2021-08-02 | 2021-08-06 | 39 | 41.62d |  | 90,152.01 |
| 42 | 1.2.3.7 | 7. TERMINACION DE ESCALERA | 8d | 2021-07-21 | 2021-07-30 | 38 | 47.62d |  | 338,041 |
| 43 | 1.2.3.8 | 8. VENTANAS | 7d | 2021-08-02 | 2021-08-10 | 39 | 39.62d |  | 190,625.7 |
| 44 | 1.2.3.9 | 9. PUERTAS | 9d | 2021-08-02 | 2021-08-12 | 39 | 37.62d |  | 74,132.37 |
| 45 | 1.2.3.10 | 10. BARANDA | 5d | 2021-08-02 | 2021-08-06 | 39 | 41.62d |  | 139,120.19 |
| 46 | 1.2.3.11 | 11. REVESTIMIENTO EN BANO | 9d | 2021-08-02 | 2021-08-12 | 39 | 37.62d |  | 24,180 |
| 47 | 1.2.3.12 | 12. INSTALACION SANITARIA | 9d | 2021-08-02 | 2021-08-12 | 39 | 26.62d | 0d | 78,604.43 |
| 48 | 1.2.3.13 | 13. PLAFOND | 9d | 2021-08-02 | 2021-08-12 | 39 | 37.62d |  | 228,619.63 |
| 49 | 1.2.3.14 | 14. PINTURA | 11d | 2021-08-02 | 2021-09-03 | 39 | 20.12d | 0d | 225,236.3 |
| 50 | 1.2.3.15 | 15. VARIOS | 9d | 2021-08-02 | 2021-08-12 | 49SS | 37.62d |  | 1,729,715.77 |
| 51 | 1.2.4 | **>> CUARTO NIVEL (CAJA DE ESCALERA) <<** | 37.5d | 2021-07-13 | 2021-08-30 |  | 24.12d |  | 3,675,987.15 |
| 52 | 1.2.4.1 | 1. REPLANTEO | 3d | 2021-07-13 | 2021-07-16 | 37 | 24.12d | 0d |  |
| 53 | 1.2.4.2 | 2. HORMIGON ARMADO | 8d | 2021-07-16 | 2021-07-27 | 52 | 24.12d | 0d | 1,729,715.77 |
| 54 | 1.2.4.3 | 3. MUROS DE BLOQUES | 5d | 2021-07-21 | 2021-07-27 | 53FS-5d | 24.12d | 0d | 286,499.31 |
| 55 | 1.2.4.4 | 4. TERMINACION DE SUPERFICIES | 9d | 2021-07-27 | 2021-08-06 | 54 | 24.12d | 0d | 335,008.92 |
| 56 | 1.2.4.5 | 5. TERMINACION DE TECHO | 5d | 2021-08-07 | 2021-08-13 | 55 | 36.62d |  | 492,691.88 |
| 57 | 1.2.4.6 | 7. TERMINACION DE ESCALERA | 8d | 2021-07-27 | 2021-08-05 | 54 | 42.62d |  | 90,152.01 |
| 58 | 1.2.4.7 | 6. VENTANAS | 7d | 2021-08-07 | 2021-08-16 | 55 | 34.62d |  | 338,041 |
| 59 | 1.2.4.8 | 7. PUERTAS | 9d | 2021-08-07 | 2021-08-18 | 55 | 32.62d |  | 190,625.7 |
| 60 | 1.2.4.9 | 8. PINTURA | 11d | 2021-08-07 | 2021-08-30 | 55 | 24.12d | 0d | 74,132.37 |
| 61 | 1.2.4.10 | 9. VARIOS | 9d | 2021-08-07 | 2021-08-18 | 60SS | 32.62d |  | 139,120.19 |

| ID | WBS | Task | Type | Duration | Start | Finish | Predecessors | Total slack | Free slack | Cost |
| --- | --- | --- | --- | --- | --- | --- | --- | --- | --- | --- |
| 62 | 1.3 | **III. BLOQUE B2** |  | 119d | 2021-04-01 | 2021-08-30 | 3SS | 20.12d |  | 17,215,869.68 |
| 63 | 1.3.1 | **>>PRIMER NIVEL.<<** |  | 65d | 2021-04-01 | 2021-06-22 |  | 20.12d |  | 5,074,627.51 |
| 64 | 1.3.1.1 | A. LIMPIEZA Y REPLANTEO | milestone | 0d | 2021-04-01 | 2021-04-01 |  | 20.12d | 0d | 10,000 |
| 65 | 1.3.1.2 | B. BAJO NIVEL DE PISO |  | 3d | 2021-04-01 | 2021-04-05 | 64 | 20.12d | 0d | 832,000 |
| 66 | 1.3.1.3 | **C. SOBRE NIVEL DE PISO** |  | 62d | 2021-04-05 | 2021-06-22 | 65 | 20.12d |  | 4,232,627.51 |
| 67 | 1.3.1.3.1 | 1. HORMIGON ARMADO |  | 25d | 2021-04-05 | 2021-05-06 |  | 20.12d | 0d | 1,729,715.77 |
| 68 | 1.3.1.3.2 | 2. MUROS DE BLOQUES |  | 11d | 2021-04-30 | 2021-05-13 | 67FS-5d | 77.62d | 0d | 286,499.31 |
| 69 | 1.3.1.3.3 | 3. TERMINACION DE SUPERFICIES |  | 9d | 2021-05-14 | 2021-05-25 | 68 | 77.62d | 0d | 335,008.92 |
| 70 | 1.3.1.3.4 | 4. TERMINACION DE PISOS |  | 9d | 2021-05-26 | 2021-06-05 | 69 | 90.62d |  | 492,691.88 |
| 71 | 1.3.1.3.5 | 5. TERMINACION DE ESCALERA |  | 5d | 2021-05-26 | 2021-06-01 | 69 | 94.62d |  | 90,152.01 |
| 72 | 1.3.1.3.6 | 7. PUERTAS |  | 9d | 2021-05-26 | 2021-06-05 | 69 | 82.62d | 0d | 338,041 |
| 73 | 1.3.1.3.7 | 8. PROTECTORES METALICOS |  | 8d | 2021-06-07 | 2021-06-16 | 72 | 82.62d |  | 190,625.7 |
| 74 | 1.3.1.3.8 | 9. REVESTIMIENTO EN BANOS |  | 5d | 2021-05-28 | 2021-06-03 | 69FS+2d | 92.62d |  | 74,132.37 |
| 75 | 1.3.1.3.9 | 10. INSTALACION SANITARIA |  | 8d | 2021-05-14 | 2021-06-12 | 68 | 79.62d | 0d | 139,120.19 |
| 76 | 1.3.1.3.10 | 11. PLAFOND |  | 9d | 2021-05-26 | 2021-06-05 | 69 | 90.62d |  | 24,180 |
| 77 | 1.3.1.3.11 | 12. ACERA PERIMETRAL |  | 5d | 2021-05-26 | 2021-06-01 | 69 | 87.62d | 0d | 78,604.43 |
| 78 | 1.3.1.3.12 | 13. PINTURA |  | 11d | 2021-05-26 | 2021-06-22 | 69 | 77.62d |  | 228,619.63 |
| 79 | 1.3.1.3.13 | 14. VARIOS |  | 7d | 2021-06-01 | 2021-06-09 | 77 | 87.62d |  | 225,236.3 |
| 80 | 1.3.2 | **>> SEGUNDO NIVEL <<** |  | 59.5d | 2021-05-06 | 2021-07-21 |  | 20.12d |  | 4,232,627.51 |
| 81 | 1.3.2.1 | 1. REPLANTEO |  | 3d | 2021-05-06 | 2021-05-10 | 67 | 20.12d | 0d |  |
| 82 | 1.3.2.2 | 2. HORMIGON ARMADO |  | 25d | 2021-05-11 | 2021-06-10 | 81 | 20.12d | 0d | 1,729,715.77 |
| 83 | 1.3.2.3 | 3. MUROS DE BLOQUES |  | 11d | 2021-06-04 | 2021-06-18 | 82FS-5d | 43.62d | 0d | 286,499.31 |
| 84 | 1.3.2.4 | 4. TERMINACION DE SUPERFICIES |  | 9d | 2021-06-18 | 2021-06-30 | 83 | 43.62d | 0d | 335,008.92 |
| 85 | 1.3.2.5 | 5. TERMINACION DE PISOS |  | 9d | 2021-06-30 | 2021-07-12 | 84 | 62.62d |  | 492,691.88 |
| 86 | 1.3.2.6 | 6. TERMINACION DE ESCALERA |  | 8d | 2021-06-18 | 2021-06-29 | 83 | 63.62d | 0d | 90,152.01 |
| 87 | 1.3.2.7 | 7. VENTANAS |  | 7d | 2021-06-30 | 2021-07-08 | 84 | 64.62d |  | 338,041 |
| 88 | 1.3.2.8 | 8. PUERTAS |  | 9d | 2021-06-30 | 2021-07-12 | 84 | 57.62d | 0d | 190,625.7 |
| 89 | 1.3.2.9 | 9. BARANDA |  | 5d | 2021-07-12 | 2021-07-17 | 88 | 57.62d |  | 74,132.37 |
| 90 | 1.3.2.10 | 10. REVESTIMIENTO EN BANO |  | 9d | 2021-06-29 | 2021-07-09 | 86 | 63.62d |  | 139,120.19 |
| 91 | 1.3.2.11 | 11. INSTALACION SANITARIA |  | 9d | 2021-06-30 | 2021-07-16 | 84 | 43.62d | 0d | 24,180 |
| 92 | 1.3.2.12 | 12. PLAFOND |  | 9d | 2021-06-30 | 2021-07-12 | 84 | 62.62d |  | 78,604.43 |
| 93 | 1.3.2.13 | 13. PINTURA |  | 11d | 2021-06-30 | 2021-07-21 | 84 | 55.12d | 0d | 228,619.63 |
| 94 | 1.3.2.14 | 14. VARIOS |  | 9d | 2021-06-30 | 2021-07-12 | 93SS | 62.62d |  | 225,236.3 |

| ID | WBS | Task | Duration | Start | Finish | Predecessors | Total slack | Free slack | Cost |
| --- | --- | --- | --- | --- | --- | --- | --- | --- | --- |
| 95 | 1.3.3 | **>> TERCER NIVEL <<** | 63d | 2021-06-11 | 2021-08-30 |  | 20.12d |  | 4,232,627.51 |
| 96 | 1.3.3.1 | 1. REPLANTEO | 3d | 2021-06-11 | 2021-06-15 | 82 | 20.12d | 0d |  |
| 97 | 1.3.3.2 | 2. HORMIGON ARMADO | 25d | 2021-06-15 | 2021-07-16 | 96 | 20.12d | 0d | 1,729,715.77 |
| 98 | 1.3.3.3 | 3. MUROS DE BLOQUES | 11d | 2021-07-10 | 2021-07-23 | 97FS-5d | 20.12d | 0d | 286,499.31 |
| 99 | 1.3.3.4 | 4. TERMINACION DE SUPERFICIES | 9d | 2021-07-24 | 2021-08-04 | 98 | 20.12d | 0d | 335,008.92 |
| 100 | 1.3.3.5 | 5. TERMINACION DE PISOS | 9d | 2021-08-05 | 2021-08-16 | 99 | 34.62d |  | 492,691.88 |
| 101 | 1.3.3.6 | 6. TERMINACION DE TECHO | 5d | 2021-08-05 | 2021-08-11 | 99 | 38.62d |  | 90,152.01 |
| 102 | 1.3.3.7 | 7. TERMINACION DE ESCALERA | 8d | 2021-07-24 | 2021-08-03 | 98 | 44.62d |  | 338,041 |
| 103 | 1.3.3.8 | 8. VENTANAS | 7d | 2021-08-05 | 2021-08-13 | 99 | 36.62d |  | 190,625.7 |
| 104 | 1.3.3.9 | 9. PUERTAS | 9d | 2021-08-05 | 2021-08-16 | 99 | 29.62d | 0d | 74,132.37 |
| 105 | 1.3.3.10 | 10. BARANDA | 5d | 2021-08-17 | 2021-08-23 | 104 | 29.62d |  | 139,120.19 |
| 106 | 1.3.3.11 | 11. REVESTIMIENTO EN BANO | 9d | 2021-08-05 | 2021-08-16 | 99 | 34.62d |  | 24,180 |
| 107 | 1.3.3.12 | 12. INSTALACION SANITARIA | 9d | 2021-08-05 | 2021-08-26 | 99 | 20.12d | 0d | 78,604.43 |
| 108 | 1.3.3.13 | 13. PLAFOND | 9d | 2021-08-05 | 2021-08-16 | 99 | 34.62d |  | 228,619.63 |
| 109 | 1.3.3.14 | 14. PINTURA | 11d | 2021-08-05 | 2021-08-30 | 99 | 23.62d | 0d | 225,236.3 |
| 110 | 1.3.3.15 | 15. VARIOS | 9d | 2021-08-05 | 2021-08-16 | 109SS | 34.62d |  |  |
| 111 | 1.3.4 | **>> CUARTO NIVEL (CAJA DE ESCALERA) <<** | 28d | 2021-07-16 | 2021-08-20 |  | 30.62d |  | 3,675,987.15 |
| 112 | 1.3.4.1 | 1. REPLANTEO | 3d | 2021-07-16 | 2021-07-20 | 97 | 30.62d | 0d |  |
| 113 | 1.3.4.2 | 2. HORMIGON ARMADO | 10d | 2021-07-21 | 2021-08-02 | 112 | 30.62d | 0d | 1,729,715.77 |
| 114 | 1.3.4.3 | 3. MUROS DE BLOQUES | 8d | 2021-07-27 | 2021-08-05 | 113FS-5d | 30.62d | 0d | 286,499.31 |
| 115 | 1.3.4.4 | 4. TERMINACION DE SUPERFICIES | 7d | 2021-08-06 | 2021-08-14 | 114 | 30.62d | 0d | 335,008.92 |
| 116 | 1.3.4.5 | 5. TERMINACION DE TECHO | 4d | 2021-08-16 | 2021-08-19 | 115 | 31.62d |  | 492,691.88 |
| 117 | 1.3.4.6 | 7. TERMINACION DE ESCALERA | 2d | 2021-08-06 | 2021-08-09 | 114 | 40.62d |  | 90,152.01 |
| 118 | 1.3.4.7 | 6. VENTANAS | 2d | 2021-08-16 | 2021-08-17 | 115 | 33.62d |  | 338,041 |
| 119 | 1.3.4.8 | 7. PUERTAS | 2d | 2021-08-16 | 2021-08-17 | 115 | 33.62d |  | 190,625.7 |
| 120 | 1.3.4.9 | 8. PINTURA | 5d | 2021-08-16 | 2021-08-20 | 115 | 30.62d | 0d | 74,132.37 |
| 121 | 1.3.4.10 | 9. VARIOS | 4d | 2021-08-16 | 2021-08-19 | 120SS | 31.62d |  | 139,120.19 |

| ID | WBS | Task | Type | Duration | Start | Finish | Predecessors | Total slack | Free slack | Cost |
| --- | --- | --- | --- | --- | --- | --- | --- | --- | --- | --- |
| 122 | 1.4 | **IV. BLOQUE B3** |  | 33d | 2021-04-01 | 2021-05-12 |  | 109.62d |  | 6,804,343.28 |
| 123 | 1.4.1 | **>>PRIMER NIVEL.<<** |  | 33d | 2021-04-01 | 2021-05-12 |  | 109.62d |  | 6,804,343.28 |
| 124 | 1.4.1.1 | A. LIMPIEZA Y REPLANTEO | milestone | 0d | 2021-04-01 | 2021-04-01 |  | 109.62d | 0d | 10,000 |
| 125 | 1.4.1.2 | B. BAJO NIVEL DE PISO | milestone | 0d | 2021-04-01 | 2021-04-01 | 124 | 109.62d | 0d | 832,000 |
| 126 | 1.4.1.3 | **C. SOBRE NIVEL DE PISO** |  | 33d | 2021-04-01 | 2021-05-12 | 125 | 109.62d |  | 5,962,343.28 |
| 127 | 1.4.1.3.1 | 1. HORMIGON ARMADO | milestone | 0d | 2021-04-01 | 2021-04-01 |  | 114.62d | 5d | 1,729,715.77 |
| 128 | 1.4.1.3.2 | 2. MUROS DE BLOQUES | milestone | 0d | 2021-04-01 | 2021-04-01 | 127FS-5d | 109.62d | 0d | 286,499.31 |
| 129 | 1.4.1.3.3 | 3. TERMINACION DE SUPERFICIES |  | 5d | 2021-04-01 | 2021-04-07 | 128 | 109.62d | 0d | 335,008.92 |
| 130 | 1.4.1.3.4 | 4. TERMINACION DE PISOS |  | 9d | 2021-04-07 | 2021-04-19 | 129 | 123.62d | 0d | 492,691.88 |
| 131 | 1.4.1.3.5 | 5. TERMINACION DE TECHO |  | 5d | 2021-04-07 | 2021-04-13 | 129 | 119.62d | 0d | 90,152.01 |
| 132 | 1.4.1.3.6 | 6. VENTANAS |  | 5d | 2021-04-14 | 2021-04-20 | 131 | 119.62d | 0d | 338,041 |
| 133 | 1.4.1.3.7 | 7. PUERTAS |  | 9d | 2021-04-07 | 2021-04-19 | 129 | 128.62d |  | 190,625.7 |
| 134 | 1.4.1.3.8 | 8. PROTECTORES METALICOS |  | 8d | 2021-04-20 | 2021-04-29 | 132 | 119.62d |  | 74,132.37 |
| 135 | 1.4.1.3.9 | 9. REVESTIMIENTO EN BANOS |  | 5d | 2021-04-19 | 2021-04-24 | 130 | 123.62d |  | 139,120.19 |
| 136 | 1.4.1.3.10 | 10. INSTALACION SANITARIA |  | 15d | 2021-04-01 | 2021-05-04 | 128 | 111.62d | 0d | 24,180 |
| 137 | 1.4.1.3.11 | 11. PLAFOND |  | 9d | 2021-04-07 | 2021-04-19 | 129 | 128.62d |  | 78,604.43 |
| 138 | 1.4.1.3.12 | 12. ACERA PERIMETRAL |  | 5d | 2021-04-07 | 2021-04-13 | 129 | 111.12d | 0d | 228,619.63 |
| 139 | 1.4.1.3.13 | 13. PINTURA |  | 10d | 2021-04-07 | 2021-05-12 | 129 | 109.62d |  | 225,236.3 |
| 140 | 1.4.1.3.14 | 14. VARIOS |  | 7d | 2021-04-14 | 2021-05-11 | 138 | 111.12d |  | 1,729,715.77 |
| 141 | 1.5 | **VI. BLOQUE B5 COMEDOR** |  | 84d | 2021-08-05 | 2021-11-20 | 3FS+20d | -41.38d | 0d | 6,699,315.19 |
| 142 | 1.5.1 | **>>PRIMER NIVEL.<<** |  | 84d | 2021-08-05 | 2021-11-20 |  | -41.38d | 0d | 6,699,315.19 |
| 143 | 1.5.1.1 | A. LIMPIEZA Y REPLANTEO | milestone | 0d | 2021-08-05 | 2021-08-05 |  | -41.38d | 0d | 286,499.31 |
| 144 | 1.5.1.2 | B. BAJO NIVEL DE PISO |  | 6d | 2021-08-06 | 2021-08-13 | 143 | -41.38d | 0d | 335,008.92 |
| 145 | 1.5.1.3 | **C. SOBRE NIVEL DE PISO** |  | 78d | 2021-08-13 | 2021-11-20 | 144 | -41.38d | 0d | 4,348,091.19 |
| 146 | 1.5.1.3.1 | 1. HORMIGON ARMADO |  | 25d | 2021-08-13 | 2021-09-14 |  | -41.38d | 0d | 90,152.01 |
| 147 | 1.5.1.3.2 | 2. MUROS DE BLOQUES |  | 11d | 2021-09-08 | 2021-09-22 | 146FS-5d | -41.38d | 0d | 338,041 |
| 148 | 1.5.1.3.3 | 3. TERMINACION DE SUPERFICIES |  | 9d | 2021-09-22 | 2021-10-04 | 147 | -40.88d | 0d | 190,625.7 |
| 149 | 1.5.1.3.4 | 4. TERMINACION DE PISOS |  | 9d | 2021-10-04 | 2021-10-14 | 148 | -12.38d | 0d | 74,132.37 |
| 150 | 1.5.1.3.5 | 5. TERMINACION DE TECHO |  | 35d | 2021-09-15 | 2021-10-28 | 146 | -40.38d | 0d | 139,120.19 |
| 151 | 1.5.1.3.6 | 6. PUERTAS |  | 5d | 2021-10-29 | 2021-11-04 | 150 | -40.38d | 0d | 24,180 |
| 152 | 1.5.1.3.7 | 7. VENTANAS |  | 9d | 2021-10-29 | 2021-11-09 | 151SS | -40.38d | 0d | 78,604.43 |
| 153 | 1.5.1.3.8 | 8. PROTECTORES METALICOS |  | 8d | 2021-11-10 | 2021-11-19 | 152 | -40.38d | 0d | 228,619.63 |
| 154 | 1.5.1.3.9 | 9. INSTALACION SANITARIA |  | 35d | 2021-09-22 | 2021-11-05 | 147 | -41.38d | 0d | 225,236.3 |
| 155 | 1.5.1.3.10 | 10. REVESTIMIENTO EN BANOS |  | 20d | 2021-10-04 | 2021-10-28 | 148 | -23.38d | 0d | 225,236.3 |
| 156 | 1.5.1.3.11 | 11. ACERA PERIMETRAL |  | 5d | 2021-11-05 | 2021-11-11 | 154 | -41.38d | 0d | 225,236.3 |
| 157 | 1.5.1.3.12 | 12. PINTURA |  | 15d | 2021-10-29 | 2021-11-19 | 148FS+20d | -40.88d | 0d | 1,729,715.77 |
| 158 | 1.5.1.3.13 | 13. VARIOS |  | 7d | 2021-11-12 | 2021-11-20 | 156 | -41.38d | 0d | 286,499.31 |

| ID | WBS | Task | Duration | Start | Finish | Predecessors | Total slack | Free slack | Cost |
| --- | --- | --- | --- | --- | --- | --- | --- | --- | --- |
| 159 | 1.6 | **VII. INSTALACION SANITARIA EXTERIOR** | 74d | 2021-04-01 | 2021-07-03 |  | 68.62d |  | 338,041 |
| 160 | 1.6.1 | 100 SANITARIA EXTERIOR | 45d | 2021-04-01 | 2021-07-03 |  | 68.62d |  | 338,041 |
| 161 | 1.7 | **VIII. CONSTRUCCION CISTERNA 8,000 gls** | 25d | 2021-04-01 | 2021-05-03 |  | 29.62d |  | 338,041 |
| 162 | 1.7.1 | 100 CONSTRUCCION CISTERNA | 25d | 2021-04-01 | 2021-05-03 |  | 29.62d | 0d | 338,041 |
| 163 | 1.8 | **IX. CONSTRUCCION CASETA SOBRE CISTERNA** | 9d | 2021-05-03 | 2021-05-13 |  | 29.62d |  | 338,041 |
| 164 | 1.8.1 | 100 CONSTRUCCION DE CASETA CISTERNA | 9d | 2021-05-03 | 2021-05-13 | 162 | 29.62d | 0d | 338,041 |
| 165 | 1.9 | **X. CAM. SEPTICA DOBLE CAMARA** | 15d | 2021-05-14 | 2021-06-02 | 164 | 29.62d |  | 338,041 |
| 166 | 1.9.1 | 100 CAMARA SEPTICA DOBLE CAMARA | 15d | 2021-05-14 | 2021-06-02 | 162 | 29.62d | 0d | 338,041 |
| 167 | 1.10 | **XI. CAM. SEPTICA DOBLE CAMARA** | 15d | 2021-06-02 | 2021-06-21 |  | 29.62d |  | 338,041 |
| 168 | 1.10.1 | 100 CAMARA SEPTICA DOBLE CAMARA | 15d | 2021-06-02 | 2021-06-21 | 166 | 29.62d | 0d | 338,041 |
| 169 | 1.11 | **XII. AREAS EXTERIORES** | 40d | 2021-09-15 | 2021-11-04 |  | -38.38d | 0d | 1,014,123 |
| 170 | 1.11.1 | 1. ACCESO PRINCIPAL, AREA CIVICA Y PATIO | 20d | 2021-09-15 | 2021-10-09 | 150FS-35d | -38.38d | 0d | 338,041 |
| 171 | 1.11.2 | 2. PAISAJISMO | 15d | 2021-10-11 | 2021-10-28 | 170 | -38.38d | 0d | 338,041 |
| 172 | 1.11.3 | 3. TARJA EN BRONCE | 5d | 2021-10-29 | 2021-11-04 | 171 | -38.38d | 0d | 338,041 |
| 173 | 1.12 | **XIII. MISCELANEOS** | 10d | 2021-10-29 | 2021-11-10 |  | -33.38d | 0d | 338,041 |
| 174 | 1.12.1 | 1 SENALIZACION Y COLOCACION DE LETRAS | 10d | 2021-10-29 | 2021-11-10 | 172SS | -33.38d | 0d | 338,041 |
| 175 | 1.13 | **XIV. VERJA PERIMETRAL** | 93d | 2021-04-01 | 2021-07-28 |  | 49.62d |  | 2,405,797.77 |
| 176 | 1.13.1 | 1. PRELIMINARES | 5d | 2021-04-01 | 2021-04-07 |  | 137.62d |  | 338,041 |
| 177 | 1.13.2 | 2. MOVIMIENTO DE TIERRA | 25d | 2021-04-01 | 2021-05-03 |  | 117.62d |  |  |
| 178 | 1.13.3 | 3. HORMIGON ARMADO | 15d | 2021-04-01 | 2021-04-20 |  | 127.62d |  | 338,041 |
| 179 | 1.13.4 | 4. BLOQUES | 15d | 2021-04-01 | 2021-04-20 |  | 127.62d |  | 1,729,715.77 |
| 180 | 1.13.5 | 5. TERMINACION DE SUPERFICIE | 15d | 2021-04-01 | 2021-04-20 |  | 127.62d |  |  |
| 181 | 1.13.6 | 7 VARIOS | 8d | 2021-04-01 | 2021-04-10 |  | 134.62d |  |  |
| 182 | 1.13.7 | 8 PINTURA | 10d | 2021-04-01 | 2021-07-28 |  | 49.62d |  |  |

| ID | WBS | Task | Duration | Start | Finish | Predecessors | Total slack | Free slack | Cost |
| --- | --- | --- | --- | --- | --- | --- | --- | --- | --- |
| 183 | 1.14 | **XV. CANCHA MIXTA** | 24d | 2021-06-22 | 2021-07-21 | 3SS | 29.62d |  | 676,082 |
| 184 | 1.14.1 | 1. PRELIMINARES | 2d | 2021-06-22 | 2021-06-23 | 168 | 29.62d | 0d | 338,041 |
| 185 | 1.14.2 | 2. MOVIMIENTO DE TIERRA | 4d | 2021-06-24 | 2021-06-29 | 184 | 29.62d | 0d |  |
| 186 | 1.14.3 | 3. HORMIGON ARMADO | 5d | 2021-06-29 | 2021-07-05 | 185 | 67.62d |  | 338,041 |
| 187 | 1.14.4 | 4. BLOQUES | 3d | 2021-06-29 | 2021-07-02 | 185 | 29.62d | 0d |  |
| 188 | 1.14.5 | 5. TERMINACION DE SUPERFICIE | 8d | 2021-07-02 | 2021-07-13 | 187 | 29.62d | 0d |  |
| 189 | 1.14.6 | 6. TERMIACION DE PISO | 5d | 2021-07-02 | 2021-07-08 | 187 | 64.62d |  |  |
| 190 | 1.14.7 | 7 VARIOS | 4d | 2021-07-13 | 2021-07-17 | 188 | 54.62d | 0d |  |
| 191 | 1.14.8 | 8 PINTURA | 3d | 2021-07-19 | 2021-07-21 | 190 | 54.62d |  |  |
| 192 | 1.15 | **XVI. GRADERIA EN CANCHA** | 22d | 2021-07-26 | 2021-08-23 |  | 29.62d |  | 338,041 |
| 193 | 1.15.1 | 1. PRELIMINARES | 1d | 2021-07-26 | 2021-07-27 | 188FS+10d | 29.62d | 0d | 338,041 |
| 194 | 1.15.2 | 2. MOVIMIENTO DE TIERRA | 3d | 2021-07-27 | 2021-07-30 | 193 | 29.62d | 0d |  |
| 195 | 1.15.3 | 3. HORMIGON ARMADO | 5d | 2021-07-30 | 2021-08-05 | 194 | 29.62d | 0d |  |
| 196 | 1.15.4 | 4. BLOQUES | 4d | 2021-08-06 | 2021-08-11 | 195 | 38.62d |  |  |
| 197 | 1.15.5 | 5. TERMINACION DE SUPERFICIE | 8d | 2021-08-06 | 2021-08-16 | 195 | 29.62d | 0d |  |
| 198 | 1.15.6 | 6. PINTURA | 4d | 2021-08-17 | 2021-08-20 | 197 | 30.62d |  |  |
| 199 | 1.15.7 | 7. VARIOS | 5d | 2021-08-17 | 2021-08-23 | 197 | 29.62d |  |  |
| 200 | 1.16 | **XVII. INSTALACION ELECTRICA** | 161d | 2021-04-01 | 2021-10-22 |  | -18.38d | 0d | 8,986,619.85 |
| 201 | 1.16.1 | **I. BLOQUE B1** | 85d | 2021-05-11 | 2021-08-26 |  | 26.62d |  | 2,067,756.77 |
| 202 | 1.16.1.1 | A. PRIMER NIVEL | 10d | 2021-05-11 | 2021-06-12 | 15SS | 85.12d |  | 1,729,715.77 |
| 203 | 1.16.1.2 | B. SEGUNDO NIVEL | 10d | 2021-06-26 | 2021-07-21 | 31SS | 54.62d |  |  |
| 204 | 1.16.1.3 | C. TERCER NIVEL | 10d | 2021-08-02 | 2021-08-26 | 47SS | 26.62d |  | 338,041 |
| 205 | 1.16.2 | **II. BLOQUE B2** | 88.5d | 2021-05-14 | 2021-09-03 |  | 20.12d |  | 1,729,715.77 |
| 206 | 1.16.2.1 | A. PRIMER NIVEL | 10d | 2021-05-14 | 2021-06-19 | 75SS | 79.62d |  | 1,729,715.77 |
| 207 | 1.16.2.2 | B. SEGUNDO NIVEL | 10d | 2021-07-17 | 2021-08-04 | 91 | 43.62d |  |  |
| 208 | 1.16.2.3 | C. TERCER NIVEL | 6d | 2021-08-26 | 2021-09-03 | 107 | 20.12d |  |  |

| ID | WBS | Task | Duration | Start | Finish | Predecessors | Total slack | Free slack | Cost |
| --- | --- | --- | --- | --- | --- | --- | --- | --- | --- |
| 209 | 1.16.3 | **III. BLOQUE B3** | 31d | 2021-04-01 | 2021-05-10 |  | 111.62d |  | 1,729,715.77 |
| 210 | 1.16.3.1 | A. PRIMER NIVEL | 10d | 2021-04-01 | 2021-05-10 | 136SS | 111.62d |  | 1,729,715.77 |
| 211 | 1.16.4 | **V. BLOQUE B5 COMEDOR** | 24d | 2021-09-22 | 2021-10-22 |  | -18.38d | 0d | 1,729,715.77 |
| 212 | 1.16.4.1 | A. PRIMER NIVEL | 15d | 2021-09-22 | 2021-10-22 | 154SS | -18.38d | 0d | 1,729,715.77 |
| 213 | 1.16.5 | **VI. BLOQUE CANCHA** | 15d | 2021-09-22 | 2021-10-11 |  | -9.38d | 0d | 1,729,715.77 |
| 214 | 1.16.5.1 | A. ELECTRIFICACION EN AREA DE CANCHA | 15d | 2021-09-22 | 2021-10-11 | 212SS | -9.38d | 0d | 1,729,715.77 |
| 215 | 1.17 | **XVIII. LIMPIEZA CONTINUA Y FINAL** | 10d | 2021-11-04 | 2021-11-17 |  | -38.38d | 0d | 338,041 |
| 216 | 1.17.1 | LIMPIEZA FINAL | 10d | 2021-11-04 | 2021-11-17 | 169 | -38.38d | 0d | 338,041 |
